# caBIG_VCDE_project_plan~105

Schedule from MS Project, 2006-03-01 to 2006-07-19, costs in $.
Mayo Foundation

## Calendars

- Standard: Mon-Fri 08:00-12:00, 13:00-17:00; Sat-Sun off. Exceptions (off unless hours are given): 2006-03-10, 2006-03-24, 2006-05-26, 2006-05-29.

## Resources

| Resource | Rate |
| --- | --- |
| DevTeam | 125 |
| PM | 62.5 |
| Architect | 62.5 |
| SEM | 62.5 |
| SQM | 62.5 |
| Reviewer | 125 |
| Sharma |  |

## Schedule

| ID | WBS | Task | Duration | Start | Finish | Predecessors | Total slack | Free slack | Resources | Work | Cost |
| --- | --- | --- | --- | --- | --- | --- | --- | --- | --- | --- | --- |
| 1 | 1 | **LexGrid Project** | 45d | 2006-03-01 | 2006-05-04 |  | 10d |  |  | 752h | 27,000 |
| 2 | 1.1 | **Project Initiation** | 3d | 2006-03-01 | 2006-03-03 |  | 94d |  |  |  |  |
| 3 | 1.1.1 | Annual Meeting | 3d | 2006-03-01 | 2006-03-03 |  | 94d |  |  |  |  |
| 4 | 1.2 | **Project Analysis** | 10d | 2006-03-01 | 2006-03-15 |  | 87d |  |  | 80h | 5,000 |
| 5 | 1.2.1 | Requirements Analysis | 5d | 2006-03-01 | 2006-03-07 |  | 87d | 0d | PM | 40h | 2,500 |
| 6 | 1.2.2 | Requirement Document | 5d | 2006-03-08 | 2006-03-15 | 5 | 87d |  | PM | 40h | 2,500 |
| 7 | 1.3 | **Project Design** | 4d | 2006-03-01 | 2006-03-07 |  | 92.4d |  |  | 32h | 2,000 |
| 8 | 1.3.1 | Model Review | 4d | 2006-03-01 | 2006-03-07 |  | 92.4d |  | Architect | 32h | 2,000 |
| 9 | 1.4 | **Software Development** | 40d | 2006-03-01 | 2006-04-27 |  | 10d |  |  | 560h | 15,000 |
| 10 | 1.4.1 | OWL Loader | 20d | 2006-03-01 | 2006-03-30 |  | 10d |  | Sharma | 160h |  |
| 11 | 1.4.2 | OBO Loader | 10d | 2006-03-31 | 2006-04-13 |  | 0d |  | Sharma | 80h |  |
| 12 | 1.4.3 | OBO Plugin | 10d | 2006-04-14 | 2006-04-27 |  | 57d |  | Sharma | 80h |  |
| 13 | 1.4.4 | **Vocabulary Services** | 35d | 2006-03-01 | 2006-04-20 |  | 0d |  |  | 240h | 15,000 |
| 14 | 1.4.4.1 | Oracle Integration | 5d | 2006-03-01 | 2006-03-07 |  | 30d |  | DevTeam | 40h | 2,500 |
| 15 | 1.4.4.2 | Loader Integration | 5d | 2006-04-14 | 2006-04-20 | 10, 11 | 0d |  | DevTeam | 40h | 2,500 |
| 16 | 1.4.4.3 | Validation Integration | 5d | 2006-03-08 | 2006-03-15 |  | 25d |  | DevTeam | 40h | 2,500 |
| 17 | 1.4.4.4 | Test Plan Extensions | 5d | 2006-03-16 | 2006-03-22 |  | 20d |  | DevTeam | 40h | 2,500 |
| 18 | 1.4.4.5 | Package Build | 5d | 2006-03-23 | 2006-03-30 |  | 15d |  | DevTeam | 40h | 2,500 |
| 19 | 1.4.4.6 | Documentation | 5d | 2006-03-31 | 2006-04-06 |  | 10d |  | DevTeam | 40h | 2,500 |
| 20 | 1.5 | **Software Testing** | 10d | 2006-04-21 | 2006-05-04 |  | 0d |  |  | 80h | 5,000 |
| 21 | 1.5.1 | Perform Software Testing | 10d | 2006-04-21 | 2006-05-04 | 13 | 0d |  | DevTeam | 80h | 5,000 |
| 22 | 2 | **LexBIO 0.5.b** | 5d | 2006-05-05 | 2006-05-11 |  | 0d |  |  | 40h | 2,500 |
| 23 | 2.1 | Software Defect Fixes | 3d | 2006-05-05 | 2006-05-09 | 20 | 0d |  | DevTeam | 24h | 1,500 |
| 24 | 2.2 | Software Build | 2d | 2006-05-10 | 2006-05-11 | 23 | 0d |  | DevTeam | 16h | 1,000 |

| ID | WBS | Task | Duration | Start | Finish | Predecessors | Total slack | Resources | Work | Cost |
| --- | --- | --- | --- | --- | --- | --- | --- | --- | --- | --- |
| 25 | 3 | **LexBIO 0.6b** | 11d | 2006-05-12 | 2006-05-30 |  | 0d |  | 88h | 5,500 |
| 26 | 3.1 | Software Enhancements | 5d | 2006-05-12 | 2006-05-18 | 22 | 0d | DevTeam | 40h | 2,500 |
| 27 | 3.2 | Software Defect Fixes | 5d | 2006-05-19 | 2006-05-25 | 26 | 0d | DevTeam | 40h | 2,500 |
| 28 | 3.3 | Education | 1d | 2006-05-30 | 2006-05-30 | 27 | 0d | DevTeam | 8h | 500 |
| 29 | 4 | **LexBIO 0.7b** | 9d | 2006-05-31 | 2006-06-12 |  | 0d |  | 72h | 4,500 |
| 30 | 4.1 | Software Enhancements | 4d | 2006-05-31 | 2006-06-05 | 25 | 0d | DevTeam | 32h | 2,000 |
| 31 | 4.2 | Software Defect Fixes | 4d | 2006-06-06 | 2006-06-09 | 30 | 0d | DevTeam | 32h | 2,000 |
| 32 | 4.3 | Education | 1d | 2006-06-12 | 2006-06-12 | 31 | 0d | DevTeam | 8h | 500 |
| 33 | 5 | **LexBIO 0.8b** | 9d | 2006-06-13 | 2006-06-23 |  | 0d |  | 72h | 4,500 |
| 34 | 5.1 | Software Enhancements | 4d | 2006-06-13 | 2006-06-16 | 29 | 0d | DevTeam | 32h | 2,000 |
| 35 | 5.2 | Software Defect Fixes | 4d | 2006-06-19 | 2006-06-22 | 34 | 0d | DevTeam | 32h | 2,000 |
| 36 | 5.3 | Education | 1d | 2006-06-23 | 2006-06-23 | 35 | 0d | DevTeam | 8h | 500 |
| 37 | 6 | **LexBIO 0.9b** | 9d | 2006-06-26 | 2006-07-06 |  | 0d |  | 72h | 4,500 |
| 38 | 6.1 | Software Enhancements | 4d | 2006-06-26 | 2006-06-29 | 33 | 0d | DevTeam | 32h | 2,000 |
| 39 | 6.2 | Software Defect Fixes | 4d | 2006-06-30 | 2006-07-05 | 38 | 0d | DevTeam | 32h | 2,000 |
| 40 | 6.3 | Education | 1d | 2006-07-06 | 2006-07-06 | 39 | 0d | DevTeam | 8h | 500 |
| 41 | 7 | **LexBIO1.0.0** | 9d | 2006-07-07 | 2006-07-19 |  | 0d |  | 72h | 4,500 |
| 42 | 7.1 | Software Enhancements | 4d | 2006-07-07 | 2006-07-12 | 37 | 0d | DevTeam | 32h | 2,000 |
| 43 | 7.2 | Software Defect Fixes | 4d | 2006-07-13 | 2006-07-18 | 42 | 0d | DevTeam | 32h | 2,000 |
| 44 | 7.3 | Education | 1d | 2006-07-19 | 2006-07-19 | 43 | 0d | DevTeam | 8h | 500 |
